# Programacion Puente Tingo_rev4

Schedule from MS Project, 2014-06-01 to 2015-01-26.

## Calendars

- Copia de Estándar: Mon-Sun 09:00-13:00, 15:00-19:00.

## Resources

| Resource |
| --- |
| 10 |

## Schedule

| ID | WBS | Task | Type | Duration | Start | Finish | Predecessors | Total slack | Free slack | Constraint |
| --- | --- | --- | --- | --- | --- | --- | --- | --- | --- | --- |
| 1 | 1 | **CONSTRUCCION DEL PUENTE TINGO Y ACCESOS** |  | 240d | 2014-06-01 | 2015-01-26 |  | 0d |  |  |
| 2 | 1.1 | INICIO DE OBRA | milestone | 0d | 2014-06-01 | 2014-06-01 |  | 0d |  |  |
| 3 | 1.2 | **TRABAJOS PRELIMINARES** |  | 238d | 2014-06-01 | 2015-01-24 |  | 2d |  |  |
| 4 | 1.2.1 | MOVILIZACIÓN Y DESMOVILIZACIÓN DE EQUIPOS |  | 14d | 2014-06-01 | 2015-01-24 | 2SS | 2d | 0d | start no earlier than 2014-06-01 |
| 5 | 1.2.2 | MOVILIZACIÓN Y DESMOVILIZACIÓN DE EQUIPO DE PILOTAJE |  | 4d | 2014-06-23 | 2014-06-27 | 21SF, 2 | 214d |  |  |
| 6 | 1.2.3 | DESBROCE Y LIMPIEZA EN ZONAS NO BOSCOSAS |  | 2d | 2014-06-03 | 2014-06-04 | 4SS+2d | 236d |  |  |
| 7 | 1.2.4 | TRAZO, REPLANTEO Y CONTROL TOPOGRAFICO |  | 3d | 2014-06-04 | 2014-06-06 | 4SS+3d | 14d | 0d |  |
| 8 | 1.2.5 | MANTENIMIENTO DE TRÁNSITO Y SEGURIDAD VIAL |  | 230d | 2014-06-01 | 2015-01-16 | 2 | 10d |  |  |
| 9 | 1.2.6 | ACCESO A CANTERAS, DME, PLANTAS Y FUENTE DE AGUA |  | 15d | 2014-06-07 | 2014-06-21 | 7 | 15d | 0d |  |
| 10 | 1.2.7 | PLATAFORMA DE OPERACIONES |  | 10d | 2014-06-07 | 2014-06-16 | 7 | 90d | 10d |  |
| 11 | 1.3 | **PUENTE TINGO** |  | 205d | 2014-06-20 | 2015-01-10 |  | 16d |  |  |
| 12 | 1.3.1 | **SUBESTRUCTURA** |  | 98d | 2014-06-20 | 2014-09-25 |  | 22d |  |  |
| 13 | 1.3.1.1 | **ESTRIBOS** |  | 98d | 2014-06-20 | 2014-09-25 |  | 22d |  |  |
| 14 | 1.3.1.1.1 | EXCAVACIÓN NO CLASIFICADA PARA ESTRUCTURAS |  | 10d | 2014-06-20 | 2014-06-29 | 9FS-2d | 22d | 0d |  |
| 15 | 1.3.1.1.2 | RELLENOS PARA ESTRUCTURAS |  | 15d | 2014-09-11 | 2014-09-25 | 16 | 100d | 0d |  |
| 16 | 1.3.1.1.3 | CONCRETO CLASE C (F'C = 280 KG/CM2) PARA ESTRIBOS |  | 10d | 2014-09-01 | 2014-09-10 | 17 | 59d | 0d |  |
| 17 | 1.3.1.1.4 | CONCRETO CLASE D (F'C = 210 KG/CM2) PARA ZAPATAS |  | 7d | 2014-08-25 | 2014-08-31 | 18FS-20d, 23, 27 | 59d | 0d |  |
| 18 | 1.3.1.1.5 | ENCOFRADO Y DESENCOFRADO PARA ESTRIBO |  | 76d | 2014-06-30 | 2014-09-13 | 14 | 59d | 0d |  |
| 19 | 1.3.1.1.6 | ACERO DE REFUERZO FY= 4200 KG/CM2 PARA ESTRIBOS |  | 40d | 2014-06-25 | 2014-08-03 | 14SS+5d | 22d | 16d |  |
| 20 | 1.3.1.2 | **PILOTE** |  | 45d | 2014-06-27 | 2014-08-10 |  | 73d |  |  |
| 21 | 1.3.1.2.1 | PILOTES (EXCAV, COLOCACION DE ARMADURA Y VACEADO CONCRETO) EN SUELOS |  | 20d | 2014-06-27 | 2014-07-16 | 10, 53SS+10d | 80d | 0d |  |
| 22 | 1.3.1.2.2 | PILOTES (EXCAV, COLOCACION DE ARMADURA Y VACEADO CONCRETO) EN ROCA |  | 7d | 2014-07-17 | 2014-07-23 | 21 | 80d | 0d |  |
| 23 | 1.3.1.2.3 | CONCRETO CLASE C (F'C = 280 KG/CM2) PARA PILOTES |  | 16d | 2014-07-19 | 2014-08-03 | 22FS-5d, 24FS-2d | 80d | 0d |  |
| 24 | 1.3.1.2.4 | ACERO DE REFUERZO PARA PILOTES FY= 4200 KG/CM2 |  | 18d | 2014-06-27 | 2014-07-14 | 21SS | 86d | 5d |  |
| 25 | 1.3.1.2.5 | DESCABEZADO DE PILOTES |  | 3d | 2014-08-05 | 2014-08-07 | 23FS+1d | 169d | 0d |  |
| 26 | 1.3.1.2.6 | PRUEBAS DE INTEGRIDAD PARA PILOTES |  | 2d | 2014-08-08 | 2014-08-09 | 25 | 169d | 0d |  |
| 27 | 1.3.1.2.7 | PRUEBA DE CARGA DINAMICA |  | 1d | 2014-08-10 | 2014-08-10 | 26 | 73d | 14d |  |

| ID | WBS | Task | Duration | Start | Finish | Predecessors | Total slack | Free slack |
| --- | --- | --- | --- | --- | --- | --- | --- | --- |
| 28 | 1.3.2 | **SUPERESTRUCTURA** | 144d | 2014-08-20 | 2015-01-10 |  | 0d |  |
| 29 | 1.3.2.1 | **VIGAS ARCO** | 63d | 2014-08-20 | 2014-10-21 |  | 6d |  |
| 30 | 1.3.2.1.1 | CONCRETO CLASE C (F'C = 280 KG/CM2) PARA VIGAS ARCO | 18d | 2014-09-11 | 2014-09-28 | 31FS-42d, 16 | 59d | 40d |
| 31 | 1.3.2.1.2 | ENCOFRADO Y DESENCOFRADO PARA VIGAS ARCO CARAVISTA | 37d | 2014-09-15 | 2014-10-21 | 48SS+26d | 0d |  |
| 32 | 1.3.2.1.3 | ACERO DE REFUERZO FY= 4200 KG/CM2 PARA VIGAS ARCO | 25d | 2014-08-20 | 2014-09-13 | 31FS-63d, 19 | 6d | 0d |
| 33 | 1.3.2.2 | **PORTICOS** | 48d | 2014-10-06 | 2014-11-22 |  | 6d |  |
| 34 | 1.3.2.2.1 | CONCRETO CLASE C (F'C = 280 KG/CM2) PARA PORTICOS | 10d | 2014-11-08 | 2014-11-17 | 35FS-15d, 30 | 19d |  |
| 35 | 1.3.2.2.2 | ENCOFRADO Y DESENCOFRADO PARA PORTICOS CARAVISTA | 32d | 2014-10-22 | 2014-11-22 | 36FS-10d, 31 | 0d |  |
| 36 | 1.3.2.2.3 | ACERO DE REFUERZO FY= 4200 KG/CM2 PARA PORTICOS | 20d | 2014-10-06 | 2014-10-25 | 32FS+22d | 6d | 0d |
| 37 | 1.3.2.3 | **VIGAS, LOSAS DE CONCRETO Y VEREDAS** | 70d | 2014-10-28 | 2015-01-05 |  | 0d |  |
| 38 | 1.3.2.3.1 | CONCRETO CLASE C (F'C = 280 KG/CM2) PARA VIGAS, LOSAS DE CONCRETO Y VEREDAS | 25d | 2014-12-07 | 2014-12-31 | 39FS-30d, 34 | 0d |  |
| 39 | 1.3.2.3.2 | ENCOFRADO Y DESENCOFRADO PARA VIGAS, LOSAS DE CONCRETO Y VEREDAS CARAVISTA | 44d | 2014-11-23 | 2015-01-05 | 40FS-15d, 47SS+10d, 35 | 0d |  |
| 40 | 1.3.2.3.3 | ACERO DE REFUERZO FY= 4200 KG/CM2 PARA VIGAS, LOSAS DE CONCRETO Y VEREDAS | 30d | 2014-10-28 | 2014-11-26 | 36FS+2d | 8d | 0d |
| 41 | 1.3.2.4 | **LOSAS DE APROXIMACION** | 23d | 2014-12-12 | 2015-01-03 |  | 0d |  |
| 42 | 1.3.2.4.1 | CONCRETO CLASE C (F'C = 280 KG/CM2) | 3d | 2015-01-01 | 2015-01-03 | 43FS-2d, 38 | 0d |  |
| 43 | 1.3.2.4.2 | ENCOFRADO Y DESENCOFRADO | 6d | 2014-12-20 | 2014-12-25 | 44 | 8d |  |
| 44 | 1.3.2.4.3 | ACERO DE REFUERZO FY= 4200 KG/CM2 | 8d | 2014-12-12 | 2014-12-19 | 40FS+15d | 8d | 0d |
| 45 | 1.3.2.5 | VARIOS | 25d | 2014-12-12 | 2015-01-05 | 38FF+5d, 42FF | 13d |  |
| 46 | 1.3.2.6 | **OBRAS TEMPORALES** | 144d | 2014-08-20 | 2015-01-10 |  | 0d |  |
| 47 | 1.3.2.6.1 | FALSO PUENTE PARA TABLERO | 64d | 2014-11-08 | 2015-01-10 | 2SS+160d | 5d |  |
| 48 | 1.3.2.6.2 | FALSO PUENTE PARA ARCO | 78d | 2014-08-20 | 2014-11-05 | 2SS+80d | 0d |  |
| 49 | 1.4 | **ACCESOS** | 229d | 2014-06-12 | 2015-01-26 |  | 0d |  |
| 50 | 1.4.1 | **MOVIMIENTO DE TIERRAS** | 211d | 2014-06-12 | 2015-01-08 |  | 18d |  |
| 51 | 1.4.1.1 | DEMOLICION DE ESTRUCTURAS | 5d | 2014-06-12 | 2014-06-16 | 7FS+5d | 75d | 0d |
| 52 | 1.4.1.2 | REMOCION DE CARPETA ASFALTICA | 5d | 2014-06-17 | 2014-06-21 | 51 | 219d |  |
| 53 | 1.4.1.3 | EXCAVACIÓN EN MATERIAL SUELTO | 20d | 2014-06-17 | 2014-07-06 | 51 | 75d | 0d |
| 54 | 1.4.1.4 | EXCAVACIÓN EN EXPLANACIONES EN ROCA FIJA | 30d | 2014-07-07 | 2014-08-05 | 53 | 151d | 0d |
| 55 | 1.4.1.5 | PERFILADO Y COMPACTADO EN ZONA DE CORTE | 1d | 2014-08-05 | 2014-08-05 | 54FF | 151d |  |
| 56 | 1.4.1.6 | CONFORMACION DE TERRAPLENES | 5d | 2015-01-04 | 2015-01-08 | 55, 68, 15, 42, 67 | 0d |  |

| ID | WBS | Task | Duration | Start | Finish | Predecessors | Total slack | Free slack |
| --- | --- | --- | --- | --- | --- | --- | --- | --- |
| 57 | 1.4.2 | **SUB BASES Y BASE** | 3d | 2015-01-09 | 2015-01-11 |  | 0d |  |
| 58 | 1.4.2.1 | BASE GRANULAR | 3d | 2015-01-09 | 2015-01-11 | 42, 56 | 0d |  |
| 59 | 1.4.3 | **PAVIMENTO ASFALTICO** | 5d | 2015-01-14 | 2015-01-18 |  | 0d |  |
| 60 | 1.4.3.1 | IMPRIMACIÓN ASFÁLTICA | 1d | 2015-01-14 | 2015-01-14 | 58FS+2d, 42 | 0d |  |
| 61 | 1.4.3.2 | RIEGO DE LIGA EN PUENTES | 1d | 2015-01-15 | 2015-01-15 | 60 | 0d |  |
| 62 | 1.4.3.3 | CONCRETO ASFALTICO EN CALIENTE | 2d | 2015-01-17 | 2015-01-18 | 61FS+1d | 0d |  |
| 63 | 1.4.3.4 | EMULSION ASFALTICA | 1d | 2015-01-14 | 2015-01-14 | 60FF | 12d |  |
| 64 | 1.4.3.5 | ASFALTO LIQUIDO MC-30 | 1d | 2015-01-16 | 2015-01-16 | 61, 60 | 10d |  |
| 65 | 1.4.4 | **OBRAS DE ARTE Y DRENAJE** | 123d | 2014-06-22 | 2014-10-22 |  | 96d |  |
| 66 | 1.4.4.1 | EXCAVACIÓN NO CLASIFICADA PARA ESTRUCTURAS | 10d | 2014-07-27 | 2014-08-05 | 53FS+20d, 14 | 75d | 0d |
| 67 | 1.4.4.2 | RELLENOS PARA ESTRUCTURAS | 8d | 2014-10-11 | 2014-10-18 | 70 | 75d | 0d |
| 68 | 1.4.4.3 | RELLENO PARA SUELO REFORZADO | 10d | 2014-10-11 | 2014-10-20 | 67SS | 75d | 0d |
| 69 | 1.4.4.4 | CONCRETO CLASE C (F'C =280 KG/CM2) | 5d | 2014-10-05 | 2014-10-09 | 72 | 109d |  |
| 70 | 1.4.4.5 | CONCRETO CLASE D (F'C = 210 KG/CM2) | 5d | 2014-10-06 | 2014-10-10 | 71 | 75d | 0d |
| 71 | 1.4.4.6 | CONCRETO CLASE C (F'C =140 KG/CM2) | 1d | 2014-10-05 | 2014-10-05 | 72 | 75d | 0d |
| 72 | 1.4.4.7 | ENCOFRADO Y DESENCOFRADO | 20d | 2014-09-15 | 2014-10-04 | 73 | 75d | 0d |
| 73 | 1.4.4.8 | ACERO DE REFUERZO FY= 4200 KG/CM2 | 20d | 2014-08-26 | 2014-09-14 | 66FS+20d | 75d | 0d |
| 74 | 1.4.4.9 | TUBERIA HDPE CORRUGADA 36 " | 4d | 2014-09-11 | 2014-09-14 | 73FF | 112d | 11d |
| 75 | 1.4.4.10 | TUBERIA HDPE CORRUGADA 4 " | 4d | 2014-09-11 | 2014-09-14 | 73FF | 112d | 11d |
| 76 | 1.4.4.11 | TUBO DE PVC-SAP, D=2 " | 3d | 2014-09-12 | 2014-09-14 | 73FF | 112d | 11d |
| 77 | 1.4.4.12 | GEOCOMPUESTO DE DRENAJE | 5d | 2014-10-06 | 2014-10-10 | 70FF | 96d | 0d |
| 78 | 1.4.4.13 | CUNETA TRIANGULAR TIPO I | 10d | 2014-09-26 | 2014-10-05 | 15, 74, 75, 76 | 101d | 0d |
| 79 | 1.4.4.14 | CUNETA RECTANGULAR | 10d | 2014-10-06 | 2014-10-15 | 78 | 101d | 0d |
| 80 | 1.4.4.15 | EMBOQUILLADO DE PIEDRA E= 0.20M | 2d | 2014-10-16 | 2014-10-17 | 79 | 101d |  |
| 81 | 1.4.4.16 | GEOTEXTIL NO TEJIDO CLASE 2 | 10d | 2014-10-11 | 2014-10-20 | 68FF | 98d |  |
| 82 | 1.4.4.17 | GEOMALLA DE POLIESTER | 10d | 2014-10-11 | 2014-10-20 | 68FF | 98d |  |
| 83 | 1.4.4.18 | GAVION TIPO CAJA | 5d | 2014-10-14 | 2014-10-18 | 67FF | 100d |  |
| 84 | 1.4.4.19 | ELEMENTO DE SUELO REFORZADO | 10d | 2014-10-11 | 2014-10-20 | 68FF, 77 | 96d | 0d |
| 85 | 1.4.4.20 | TAPA DE CONCRETO PARA BUZON | 2d | 2014-10-21 | 2014-10-22 | 84 | 96d |  |
| 86 | 1.4.4.21 | TUBERIA HDPE CORRUGADA 12" | 2d | 2014-06-22 | 2014-06-23 | 9 | 201d | 0d |
| 87 | 1.4.4.22 | EXCAVACION EN EXPLANACIONES EN ROCA FIJA | 3d | 2014-06-24 | 2014-06-26 | 86 | 201d | 0d |
| 88 | 1.4.4.23 | ROCA ACOMODADA | 10d | 2014-06-27 | 2014-07-06 | 87 | 201d | 0d |
| 89 | 1.4.4.24 | ENCAUZAMIENTO | 3d | 2014-07-07 | 2014-07-09 | 88 | 201d |  |

| ID | WBS | Task | Duration | Start | Finish | Predecessors | Total slack | Free slack |
| --- | --- | --- | --- | --- | --- | --- | --- | --- |
| 90 | 1.4.5 | **TRANSPORTE** | 210d | 2014-06-20 | 2015-01-15 |  | 11d |  |
| 91 | 1.4.5.1 | TRANSPORTE DE DESECHOS Y EXCEDENTES A DME PARA D<1KM | 210d | 2014-06-20 | 2015-01-15 | 59FF-3d, 9SS+2d | 11d | 0d |
| 92 | 1.4.5.2 | TRANSPORTE DE DESECHOS Y EXCEDENTES A DME PARA D>=1KM | 210d | 2014-06-20 | 2015-01-15 | 91FF | 11d |  |
| 93 | 1.4.6 | **SEÑALIZACION Y SEGURIDAD VIAL** | 174d | 2014-08-06 | 2015-01-26 |  | 0d |  |
| 94 | 1.4.6.1 | SEÑALES PREVENTIVAS 0.75m x 0.75m | 20d | 2014-12-26 | 2015-01-14 | 58FF+3d | 7d | 0d |
| 95 | 1.4.6.2 | SEÑAL PREVENTIVA TRIANGULAR 1.00 DE LADO | 10d | 2015-01-09 | 2015-01-18 | 94SS+14d | 7d | 0d |
| 96 | 1.4.6.3 | SEÑALES REGLAMENTARIAS 1.20m x 0.80m | 10d | 2015-01-09 | 2015-01-18 | 95SS | 7d | 0d |
| 97 | 1.4.6.4 | SEÑAL REGLAMENTARIA OCTOGONAL 0.75m x 0.75m | 5d | 2015-01-09 | 2015-01-13 | 96SS | 7d | 0d |
| 98 | 1.4.6.5 | SEÑALES INFORMATIVAS | 8d | 2015-01-09 | 2015-01-16 | 97SS | 7d | 0d |
| 99 | 1.4.6.6 | POSTES DE SOPORTE DE SEÑALES DE CONCRETO | 2d | 2015-01-09 | 2015-01-10 | 98SS | 7d | 0d |
| 100 | 1.4.6.7 | POSTES METALICOS ADOSADOS | 2d | 2015-01-09 | 2015-01-10 | 99SS | 7d | 0d |
| 101 | 1.4.6.8 | ESTRUCTURAS DE SOPORTE DE SEÑALES TIPO E-1 | 2d | 2015-01-09 | 2015-01-10 | 100SS | 7d | 0d |
| 102 | 1.4.6.9 | TACHA RETROREFLECTIVA | 3d | 2015-01-24 | 2015-01-26 | 103 | 0d |  |
| 103 | 1.4.6.10 | MARCAS EN EL PAVIMENTO | 5d | 2015-01-19 | 2015-01-23 | 62, 104 | 0d |  |
| 104 | 1.4.6.11 | PINTADO DE PARAPETOS DE MUROS, ALCANTARILLAS | 1d | 2015-01-11 | 2015-01-11 | 101 | 7d |  |
| 105 | 1.4.6.12 | RETIRO TOTAL DE SEÑAL VERTICAL | 1d | 2014-08-06 | 2014-08-06 | 54 | 173d |  |
| 106 | 1.4.6.13 | RETIRO TOTAL DE SEÑAL INFORMATIVA, NO INCLUYE DEMOLICION | 1d | 2014-08-06 | 2014-08-06 | 54 | 173d |  |
| 107 | 1.4.6.14 | RETIRO DE ESTRUCTURAS DE SOPORTE DE SEÑALES | 1d | 2014-08-06 | 2014-08-06 | 54 | 173d |  |
| 108 | 1.5 | **PROTECCIÓN AMBIENTAL** | 234d | 2014-06-01 | 2015-01-20 |  | 6d |  |
| 109 | 1.5.1 | **PROGRAMA DE CIERRE DE OBRA** | 226d | 2014-06-09 | 2015-01-20 |  | 6d |  |
| 110 | 1.5.1.1 | RETIRO, ALMACENAMIENTO Y REPOSICION DE TOP SOIL | 30d | 2014-06-10 | 2015-01-16 | 7, 112SF | 11d |  |
| 111 | 1.5.1.2 | CONFORMACION FINAL A DME | 212d | 2014-06-09 | 2015-01-06 | 9SS+2d | 15d | 0d |
| 112 | 1.5.1.3 | REVEGETACION | 5d | 2015-01-16 | 2015-01-20 | 114FF, 111 | 6d | 0d |
| 113 | 1.5.1.4 | DISPOSICION Y CONFORMACION DE MATERIAL EXCEDENTE | 210d | 2014-06-11 | 2015-01-06 | 111FF | 20d |  |
| 114 | 1.5.1.5 | READECUACION AMBIENTAL DE CANTERAS DE RIO | 15d | 2015-01-06 | 2015-01-20 | 115FF | 6d | 0d |
| 115 | 1.5.1.6 | READECUACION AMBIENTAL DE PLANTAS DE TRITURACION | 15d | 2015-01-06 | 2015-01-20 | 116FF | 6d | 0d |
| 116 | 1.5.1.7 | READECUACION AMBIENTAL DEL CAMPAMENTO | 15d | 2015-01-06 | 2015-01-20 | 117FF | 6d | 0d |
| 117 | 1.5.1.8 | READECUACION AMBIENTAL DEL PATIO DE MAQUINAS | 12d | 2015-01-09 | 2015-01-20 | 62FF, 58SS | 6d | 0d |

| ID | WBS | Task | Duration | Start | Finish | Predecessors | Total slack | Free slack | Constraint |
| --- | --- | --- | --- | --- | --- | --- | --- | --- | --- |
| 118 | 1.5.2 | **SUB PROGRAMA DE SEÑALIZACIÓN AMBIENTAL** | 2d | 2015-01-09 | 2015-01-10 |  | 16d |  |  |
| 119 | 1.5.2.1 | SEÑAL INFORMATIVA AMBIENTAL | 1d | 2015-01-09 | 2015-01-09 | 98SS | 16d | 0d |  |
| 120 | 1.5.2.2 | ESTRUCTURA DE SOPORTE DE SEÑAL AMBIENTAL | 1d | 2015-01-10 | 2015-01-10 | 119 | 16d |  |  |
| 121 | 1.5.3 | **PROGRAMA DE MONITOREO AMBIENTAL** | 231d | 2014-06-01 | 2015-01-17 |  | 9d |  |  |
| 122 | 1.5.3.1 | MONITOREO DE LA CALIDAD DEL AGUA | 28d | 2014-06-01 | 2015-01-16 | 2 | 10d |  |  |
| 123 | 1.5.3.2 | MONITOREO DE LA CALIDAD DEL AIRE | 28d | 2014-06-01 | 2015-01-16 | 2 | 10d |  |  |
| 124 | 1.5.3.3 | MONITOREO DE NIVEL DE PRESION DE RUIDOS | 28d | 2014-06-01 | 2015-01-16 | 2 | 10d |  |  |
| 125 | 1.5.3.4 | MONITOREO DE SUELO | 28d | 2014-06-02 | 2015-01-17 | 2 | 9d |  | start no earlier than 2014-06-02 |
